# Gantt-Task allocation 08-06-18

How a schedule from MS Project changed from version to version. A marks actual dates.

## Version 1 (data date 2018-03-01, saved 2018-06-15, file Gantt-Task allocation 08-06-18.mpp)

| ID | WBS | Task | Duration | Start | Finish | Predecessors | Complete | Total float | Constraint |
| --- | --- | --- | --- | --- | --- | --- | --- | --- | --- |
| 1 | 1 | **Outdoor Intelligent Shader** | 75d | 2018-02-26 A | 2018-06-25 |  | 90% | 0d |  |
| 2 | 1.1 | **Analysing** | 3d | 2018-02-26 A | 2018-02-28 A |  | 100% |  |  |
| 3 | 1.1.1 | **Planning** | 3d | 2018-02-26 A | 2018-02-28 A |  | 100% |  |  |
| 4 |  | Problem | 1d | 2018-02-26 A | 2018-02-26 A |  | 100% |  |  |
| 5 | 1.1.1.2 | **Target Audience** | 1d | 2018-02-26 A | 2018-02-26 A |  | 100% |  |  |
| 6 |  | Research User | 1d | 2018-02-26 A | 2018-02-26 A |  | 100% |  |  |
| 7 |  | Existing Products | 1d | 2018-02-27 A | 2018-02-27 A | 5 | 100% |  |  |
| 8 | 1.1.1.4 | **Economical Analisys** | 1d | 2018-02-27 A | 2018-02-27 A | 7SS | 100% |  |  |
| 9 |  | SWOT | 1d | 2018-02-27 A | 2018-02-27 A |  | 100% |  |  |
| 10 |  | Requirements | 1d | 2018-02-28 A | 2018-02-28 A | 7 | 100% |  |  |
| 11 | 1.2 | **Ideation** | 3d | 2018-03-01 A | 2018-03-05 A | 2 | 100% |  |  |
| 12 | 1.2.1 | **Analysing** | 3d | 2018-03-01 A | 2018-03-05 A |  | 100% |  |  |
| 13 | 1.2.1.1 | **Product View** | 1d | 2018-03-01 A | 2018-03-01 A |  | 100% |  |  |
| 14 |  | Intentions | 1d | 2018-03-01 A | 2018-03-01 A |  | 100% |  |  |
| 15 |  | Perception | 1d | 2018-03-01 A | 2018-03-01 A |  | 100% |  |  |
| 16 |  | Aesthetics | 1d | 2018-03-01 A | 2018-03-01 A |  | 100% |  |  |
| 17 |  | Product Ideas(20-40 ideas) | 1d | 2018-03-01 A | 2018-03-01 A | 13SS | 100% |  |  |
| 18 |  | 10 improved ideas | 1d | 2018-03-02 A | 2018-03-02 A | 17 | 100% |  |  |
| 19 |  | Morfological Research | 1d | 2018-03-05 A | 2018-03-05 A | 18 | 100% |  |  |
| 20 |  | Gantt chart | 0d | 2018-03-05 A | 2018-03-05 A |  | 100% |  | start no earlier than 2018-03-05 |
| 21 |  | Task identification | 0d | 2018-03-05 A | 2018-03-05 A |  | 100% |  | start no earlier than 2018-03-05 |
| 22 |  | Task allocation | 0d | 2018-03-05 A | 2018-03-05 A |  | 100% |  | start no earlier than 2018-03-05 |
| 23 | 1.3 | **Concept** | 31d | 2018-03-06 A | 2018-04-25 A | 11 | 100% |  |  |
| 24 | 1.3.1 | **Analysing** | 31d | 2018-03-06 A | 2018-04-25 A |  | 100% |  |  |
| 25 |  | 3 concepts | 1d | 2018-03-06 A | 2018-03-06 A |  | 100% |  |  |
| 26 | 1.3.1.2 | **Final Concept** | 30d | 2018-03-07 A | 2018-04-25 A | 25 | 100% |  |  |
| 27 |  | Black Box, structural drafts | 4d | 2018-03-07 A | 2018-03-12 A |  | 100% |  |  |
| 28 |  | Upload black Box, structural drafts | 0d | 2018-03-12 A | 2018-03-12 A | 27 | 100% |  |  |
| 29 |  | Detailed schematics, structural drawings,cardboard model | 15d | 2018-03-13 A | 2018-04-02 A | 27 | 100% |  |  |
| 30 |  | Upload Detailed schematics, structural drawings,cardboard model | 0d | 2018-04-02 A | 2018-04-02 A | 29 | 100% |  | finish no earlier than 2018-04-02 |
| 31 |  | Choosing materials | 4d | 2018-04-03 A | 2018-04-06 A | 29 | 100% |  |  |
| 32 |  | Upload selection of materials and components | 0d | 2018-04-04 A | 2018-04-04 A | 31 | 100% |  |  |
| 33 |  | Search local providers | 13d | 2018-04-09 A | 2018-04-25 A | 31 | 100% |  |  |
| 34 |  | Upload selection of local providers and final list of materials and components | 0d | 2018-04-25 A | 2018-04-25 A | 33 | 100% |  |  |
| 35 | 1.4 | **Interim Presentation** | 11d | 2018-04-05 A | 2018-04-19 A | 32 | 100% |  |  |
| 36 | 1.4.1 | **Planning** | 11d | 2018-04-05 A | 2018-04-19 A |  | 100% |  |  |
| 37 |  | Evaluation meetings | 11d | 2018-04-05 A | 2018-04-19 A |  | 100% |  |  |
| 38 |  | Upload deliverables | 0d | 2018-04-14 A | 2018-04-14 A |  | 100% |  | start no earlier than 2018-04-14 |
| 39 |  | Presentation | 0d | 2018-04-19 A | 2018-04-19 A | 37 | 100% |  |  |
| 40 | 1.5 | **Construction** | 14d | 2018-04-26 A | 2018-05-22 A | 23 | 100% |  |  |
| 41 | 1.5.1 | **Planning** | 14d | 2018-04-26 A | 2018-05-22 A |  | 100% |  |  |
| 42 | 1.5.1.1 | **Hardware** | 14d | 2018-04-26 A | 2018-05-22 A |  | 100% |  |  |
| 43 |  | Process material matrix | 1d | 2018-04-26 A | 2018-04-26 A |  | 100% |  |  |
| 44 | 1.5.1.1.2 | **Materials** | 1d | 2018-04-27 A | 2018-04-27 A | 43 | 100% |  |  |
| 45 |  | Sustainability | 1d | 2018-04-27 A | 2018-04-27 A |  | 100% |  |  |
| 46 | 1.5.1.1.3 | **Processes** | 12d | 2018-04-30 A | 2018-05-22 A | 44 | 100% |  |  |
| 47 |  | Shaping | 12d | 2018-04-30 A | 2018-05-22 A |  | 100% |  |  |
| 48 |  | Joining | 12d | 2018-04-30 A | 2018-05-22 A |  | 100% |  |  |
| 49 | 1.5.1.2 | **Software** | 12d | 2018-04-30 A | 2018-05-22 A | 46SS | 100% |  |  |
| 50 |  | Materials | 12d | 2018-04-30 A | 2018-05-22 A |  | 100% |  |  |
| 51 |  | Specifics | 12d | 2018-04-30 A | 2018-05-22 A |  | 100% |  |  |
| 52 |  | Upload refined report | 0d | 2018-05-02 A | 2018-05-02 A |  | 100% |  | start no earlier than 2018-05-02 |
| 53 | 1.6 | **Testing** | 11d | 2018-05-23 A | 2018-06-06 | 40 | 80% | 0d |  |
| 54 |  | Component tests | 11d | 2018-05-23 A | 2018-06-06 |  | 80% | 0d |  |
| 55 |  | Upload functional tests | 0d | 2018-06-06 | 2018-06-06 | 54 |  | 0d |  |
| 56 | 1.7 | **Report** | 10d | 2018-06-07 A | 2018-06-20 | 53 | 20% | 0d |  |
| 57 |  | Write final report | 10d | 2018-06-07 A | 2018-06-20 |  | 20% | 0d |  |
| 58 |  | Upload final report | 0d | 2018-06-20 | 2018-06-20 | 57 |  | 0d |  |
| 59 |  | Upload Deliverables | 0d | 2018-06-20 | 2018-06-20 | 57 |  | 0d |  |
| 60 | 1.8 | **Final Presentation** | 3d | 2018-06-21 | 2018-06-25 | 56 |  | 0d |  |
| 61 |  | Evaluation meetings | 3d | 2018-06-21 | 2018-06-25 |  |  | 0d |  |
| 62 |  | Presentation | 0d | 2018-06-25 | 2018-06-25 | 61 |  | 0d |  |

## Version 2 (data date 2018-04-06, saved 2018-04-25, file Gantt-Task allocation 06-04-18.mpp)

Last finish stays 2018-06-25. Complete tasks 33 → 19.

Changed:

| ID | Task | Start | Finish | Complete | Total float |
| --- | --- | --- | --- | --- | --- |
| 1 | **Outdoor Intelligent Shader** |  |  | 90% → 13% |  |
| 23 | **Concept** |  | 2018-04-25 A → 2018-04-25 | 100% → 16% | none → 0d |
| 24 | **Analysing** |  | 2018-04-25 A → 2018-04-25 | 100% → 16% | none → 0d |
| 26 | **Final Concept** |  | 2018-04-25 A → 2018-04-25 | 100% → 14% | none → 0d |
| 29 | Detailed schematics, structural drawings,cardboard model |  | 2018-04-02 A → 2018-04-02 | 100% → 7% | none → 0d |
| 31 | Choosing materials | 2018-04-03 A → 2018-04-03 | 2018-04-06 A → 2018-04-06 | 100% → 0% | none → 0d |
| 33 | Search local providers | 2018-04-09 A → 2018-04-09 | 2018-04-25 A → 2018-04-25 | 100% → 0% | none → 0d |
| 34 | Upload selection of local providers and final list of materials and components | 2018-04-25 A → 2018-04-25 | 2018-04-25 A → 2018-04-25 | 100% → 0% | none → 0d |
| 35 | **Interim Presentation** | 2018-04-05 A → 2018-04-05 | 2018-04-19 A → 2018-04-19 | 100% → 0% | none → 42d |
| 36 | **Planning** | 2018-04-05 A → 2018-04-05 | 2018-04-19 A → 2018-04-19 | 100% → 0% | none → 42d |
| 37 | Evaluation meetings | 2018-04-05 A → 2018-04-05 | 2018-04-19 A → 2018-04-19 | 100% → 0% | none → 42d |
| 38 | Upload deliverables | 2018-04-14 A → 2018-04-14 | 2018-04-14 A → 2018-04-14 | 100% → 0% | none → 46d |
| 39 | Presentation | 2018-04-19 A → 2018-04-19 | 2018-04-19 A → 2018-04-19 | 100% → 0% | none → 42d |
| 40 | **Construction** | 2018-04-26 A → 2018-04-26 | 2018-05-22 A → 2018-05-22 | 100% → 0% | none → 0d |
| 41 | **Planning** | 2018-04-26 A → 2018-04-26 | 2018-05-22 A → 2018-05-22 | 100% → 0% | none → 0d |
| 42 | **Hardware** | 2018-04-26 A → 2018-04-26 | 2018-05-22 A → 2018-05-22 | 100% → 0% | none → 0d |
| 43 | Process material matrix | 2018-04-26 A → 2018-04-26 | 2018-04-26 A → 2018-04-26 | 100% → 0% | none → 0d |
| 44 | **Materials** | 2018-04-27 A → 2018-04-27 | 2018-04-27 A → 2018-04-27 | 100% → 0% | none → 0d |
| 45 | Sustainability | 2018-04-27 A → 2018-04-27 | 2018-04-27 A → 2018-04-27 | 100% → 0% | none → 0d |
| 46 | **Processes** | 2018-04-30 A → 2018-04-30 | 2018-05-22 A → 2018-05-22 | 100% → 0% | none → 0d |
| 47 | Shaping | 2018-04-30 A → 2018-04-30 | 2018-05-22 A → 2018-05-22 | 100% → 0% | none → 0d |
| 48 | Joining | 2018-04-30 A → 2018-04-30 | 2018-05-22 A → 2018-05-22 | 100% → 0% | none → 0d |
| 49 | **Software** | 2018-04-30 A → 2018-04-30 | 2018-05-22 A → 2018-05-22 | 100% → 0% | none → 0d |
| 50 | Materials | 2018-04-30 A → 2018-04-30 | 2018-05-22 A → 2018-05-22 | 100% → 0% | none → 0d |
| 51 | Specifics | 2018-04-30 A → 2018-04-30 | 2018-05-22 A → 2018-05-22 | 100% → 0% | none → 0d |
| 52 | Upload refined report | 2018-05-02 A → 2018-05-02 | 2018-05-02 A → 2018-05-02 | 100% → 0% | none → 10d |
| 53 | **Testing** | 2018-05-23 A → 2018-05-23 |  | 80% → 0% |  |
| 54 | Component tests | 2018-05-23 A → 2018-05-23 |  | 80% → 0% |  |
| 56 | **Report** | 2018-06-07 A → 2018-06-07 |  | 20% → 0% |  |
| 57 | Write final report | 2018-06-07 A → 2018-06-07 |  | 20% → 0% |  |

## Version 3 (data date 2018-04-13, saved 2018-04-28, file Gantt-Task allocation 13-04-18.mpp)

Last finish stays 2018-06-25. Complete tasks 19 → 21.

Changed:

| ID | Task | Start | Finish | Complete | Total float |
| --- | --- | --- | --- | --- | --- |
| 1 | **Outdoor Intelligent Shader** |  |  | 13% → 35% |  |
| 23 | **Concept** |  |  | 16% → 78% |  |
| 24 | **Analysing** |  |  | 16% → 78% |  |
| 26 | **Final Concept** |  |  | 14% → 78% |  |
| 29 | Detailed schematics, structural drawings,cardboard model |  | 2018-04-02 A | 7% → 100% | 0d → none |
| 31 | Choosing materials | 2018-04-03 A | 2018-04-06 A | 0% → 100% | 0d → none |
| 33 | Search local providers | 2018-04-09 A |  | 0% → 38% |  |
| 35 | **Interim Presentation** | 2018-04-05 A |  | 0% → 64% |  |
| 36 | **Planning** | 2018-04-05 A |  | 0% → 64% |  |
| 37 | Evaluation meetings | 2018-04-05 A |  | 0% → 64% |  |

## Version 4 (data date 2018-04-20, saved 2018-04-29, file Gantt-Task allocation 20-04-18.mpp)

Last finish stays 2018-06-25. Complete tasks 21 → 24.

Changed:

| ID | Task | Start | Finish | Complete | Total float |
| --- | --- | --- | --- | --- | --- |
| 1 | **Outdoor Intelligent Shader** |  |  | 35% → 43% |  |
| 23 | **Concept** |  |  | 78% → 96% |  |
| 24 | **Analysing** |  |  | 78% → 96% |  |
| 26 | **Final Concept** |  |  | 78% → 96% |  |
| 33 | Search local providers |  |  | 38% → 90% |  |
| 35 | **Interim Presentation** |  | 2018-04-19 A | 64% → 100% | 42d → none |
| 36 | **Planning** |  | 2018-04-19 A | 64% → 100% | 42d → none |
| 37 | Evaluation meetings |  | 2018-04-19 A | 64% → 100% | 42d → none |
| 38 | Upload deliverables | 2018-04-14 A | 2018-04-14 A | 0% → 100% | 46d → none |
| 39 | Presentation | 2018-04-19 A | 2018-04-19 A | 0% → 100% | 42d → none |

## Version 5 (data date 2018-04-27, saved 2018-05-01, file Gantt-Task allocation 27-04-18.mpp)

Last finish stays 2018-06-25. Complete tasks 24 → 28.

Changed:

| ID | Task | Start | Finish | Complete | Total float |
| --- | --- | --- | --- | --- | --- |
| 1 | **Outdoor Intelligent Shader** |  |  | 43% → 46% |  |
| 23 | **Concept** |  | 2018-04-25 A | 96% → 100% | 0d → none |
| 24 | **Analysing** |  | 2018-04-25 A | 96% → 100% | 0d → none |
| 26 | **Final Concept** |  | 2018-04-25 A | 96% → 100% | 0d → none |
| 33 | Search local providers |  | 2018-04-25 A | 90% → 100% | 0d → none |
| 34 | Upload selection of local providers and final list of materials and components | 2018-04-25 A | 2018-04-25 A | 0% → 100% | 0d → none |
| 40 | **Construction** | 2018-04-26 A |  | 0% → 4% |  |
| 41 | **Planning** | 2018-04-26 A |  | 0% → 4% |  |
| 42 | **Hardware** | 2018-04-26 A |  | 0% → 8% |  |
| 43 | Process material matrix | 2018-04-26 A | 2018-04-26 A | 0% → 100% | 0d → none |
| 44 | **Materials** | 2018-04-27 A | 2018-04-27 A | 0% → 100% | 0d → none |
| 45 | Sustainability | 2018-04-27 A | 2018-04-27 A | 0% → 100% | 0d → none |

## Version 6 (data date 2018-05-04, saved 2018-05-14, file Gantt-Task allocation 04-05-18.mpp)

Last finish stays 2018-06-25. Complete tasks 28 → 29.

Changed:

| ID | Task | Start | Finish | Complete | Total float |
| --- | --- | --- | --- | --- | --- |
| 1 | **Outdoor Intelligent Shader** |  |  | 46% → 61% |  |
| 40 | **Construction** |  |  | 4% → 44% |  |
| 41 | **Planning** |  |  | 4% → 44% |  |
| 42 | **Hardware** |  |  | 8% → 46% |  |
| 46 | **Processes** | 2018-04-30 A |  | 0% → 42% |  |
| 47 | Shaping | 2018-04-30 A |  | 0% → 42% |  |
| 48 | Joining | 2018-04-30 A |  | 0% → 42% |  |
| 49 | **Software** | 2018-04-30 A |  | 0% → 42% |  |
| 50 | Materials | 2018-04-30 A |  | 0% → 42% |  |
| 51 | Specifics | 2018-04-30 A |  | 0% → 42% |  |
| 52 | Upload refined report | 2018-05-02 A | 2018-05-02 A | 0% → 100% | 10d → none |

## Version 7 (data date 2018-05-18, saved 2018-05-20, file Gantt-Task allocation 18-05-18.mpp)

Last finish stays 2018-06-25.

Changed:

| ID | Task | Complete |
| --- | --- | --- |
| 1 | **Outdoor Intelligent Shader** | 61% → 76% |
| 40 | **Construction** | 44% → 84% |
| 41 | **Planning** | 44% → 84% |
| 42 | **Hardware** | 46% → 85% |
| 46 | **Processes** | 42% → 83% |
| 47 | Shaping | 42% → 83% |
| 48 | Joining | 42% → 83% |
| 49 | **Software** | 42% → 83% |
| 50 | Materials | 42% → 83% |
| 51 | Specifics | 42% → 83% |

## Version 8 (data date 2018-06-01, saved 2018-06-07, file Gantt-Task allocation 01-06-18.mpp)

Last finish stays 2018-06-25. Complete tasks 29 → 33.

Changed:

| ID | Task | Start | Finish | Complete | Total float |
| --- | --- | --- | --- | --- | --- |
| 1 | **Outdoor Intelligent Shader** |  |  | 76% → 88% |  |
| 40 | **Construction** |  | 2018-05-22 A | 84% → 100% | 0d → none |
| 41 | **Planning** |  | 2018-05-22 A | 84% → 100% | 0d → none |
| 42 | **Hardware** |  | 2018-05-22 A | 85% → 100% | 0d → none |
| 46 | **Processes** |  | 2018-05-22 A | 83% → 100% | 0d → none |
| 47 | Shaping |  | 2018-05-22 A | 83% → 100% | 0d → none |
| 48 | Joining |  | 2018-05-22 A | 83% → 100% | 0d → none |
| 49 | **Software** |  | 2018-05-22 A | 83% → 100% | 0d → none |
| 50 | Materials |  | 2018-05-22 A | 83% → 100% | 0d → none |
| 51 | Specifics |  | 2018-05-22 A | 83% → 100% | 0d → none |
| 53 | **Testing** | 2018-05-23 A |  | 0% → 73% |  |
| 54 | Component tests | 2018-05-23 A |  | 0% → 73% |  |

## Version 9 (data date 2018-06-15, saved 2018-06-17, file Gantt-Task allocation 15-06-18.mpp)

Last finish stays 2018-06-25. Complete tasks 33 → 35.

Changed:

| ID | Task | Start | Finish | Complete | Total float | Other |
| --- | --- | --- | --- | --- | --- | --- |
| 1 | **Outdoor Intelligent Shader** |  |  | 88% → 95% |  |  |
| 47 | Shaping |  |  |  |  | resources Sven Bergervoet → Sven Bergervoet; Bearing 8mm interior; Bearing 10mm interior; Cloth; MDF panel 1200*600*10mm; Pulley; Transmission Belt; Transportation costs from RepRap; Wood Bar; Wood beam 44*44*2600; Wood Glue |
| 48 | Joining |  |  |  |  | resources Manuel Baptista → Manuel Baptista; Bearing 8mm interior; Bearing 10mm interior; Cloth; MDF panel 1200*600*10mm; Pulley; Transmission Belt; Wood Bar; Wood beam 44*44*2600; Wood Glue |
| 50 | Materials |  |  |  |  | resources Cristopher Mahon → Cristopher Mahon; 10 kΩ Resistor; 12 V Power Supply; Arduino UNO; Breadboard; DC Motor; HC-05 Bluetooth Receiver; L298 H Bridge; Logic-Level Translator; Proximity sensor [200%]; RTC DS1307; Switch |
| 51 | Specifics |  |  |  |  | resources Melanie Tscholl → Melanie Tscholl; 10 kΩ Resistor; 12 V Power Supply; Arduino UNO; Breadboard; DC Motor; HC-05 Bluetooth Receiver; L298 H Bridge; Logic-Level Translator; Proximity sensor [200%]; RTC DS1307; Switch |
| 53 | **Testing** |  | 2018-06-06 A | 73% → 100% | 0d → none |  |
| 54 | Component tests |  | 2018-06-06 A | 73% → 100% | 0d → none | resources Cristopher Mahon; Manuel Baptista; Marta Majewska; Melanie Tscholl; Sven Bergervoet → Cristopher Mahon; Manuel Baptista; Marta Majewska; Melanie Tscholl; Sven Bergervoet; 10 kΩ Resistor; 12 V Power Supply; Arduino UNO; Breadboard; DC Motor; HC-05 Bluetooth Receiver; L298 H Bridge; Logic-Level Translator; Proximity sensor; RTC DS1307; Switch |
| 55 | Upload functional tests | 2018-06-06 A | 2018-06-06 A | 0% → 100% | 0d → none | resources Cristopher Mahon; Manuel Baptista; Marta Majewska; Melanie Tscholl; Sven Bergervoet → Cristopher Mahon; Melanie Tscholl |
| 56 | **Report** | 2018-06-07 A |  | 0% → 70% |  |  |
| 57 | Write final report | 2018-06-07 A |  | 0% → 70% |  |  |
